# anexo 1

Schedule from MS Project, 2016-01-04 to 2016-07-01.
Hewlett-Packard Company

## Calendars

- calendario: Mon-Sun 09:00-13:00, 15:00-19:00.

## Resources

| Resource |
| --- |
| Roberto Arce |

## Schedule

| ID | WBS | Task | Duration | Start | Finish | Predecessors | Total slack | Free slack | Constraint | Text1 |
| --- | --- | --- | --- | --- | --- | --- | --- | --- | --- | --- |
| 1 | 1 | **Estudio de Ingeniería basica Extendida (IBE)** | 180d | 2016-01-04 | 2016-07-01 |  | 0d |  |  | Roberto Arce |
| 2 | 1.1 | **Documento Soporte de Decisión 1** | 60d | 2016-01-04 | 2016-03-03 |  | 59d |  |  |  |
| 3 | 1.1.1 | Metodología para la selección de poblaciones y proyección de la demanda de gas natural | 12d | 2016-01-04 | 2016-01-15 |  | 120d | 0d | start no earlier than 2016-01-04 |  |
| 4 | 1.1.2 | Selección de las Poblaciones | 22d | 2016-01-16 | 2016-02-06 | 3 | 146d |  |  |  |
| 5 | 1.1.3 | **Estudio de la demanda de gas natural** | 53d | 2016-01-11 | 2016-03-03 |  | 120d |  |  |  |
| 6 | 1.1.3.1 | Estadisticas de cada población seleccionada | 45d | 2016-01-11 | 2016-02-24 | 3SS+7d | 120d | 0d |  |  |
| 7 | 1.1.3.2 | Proyección de la demanda de gas natural | 46d | 2016-01-18 | 2016-03-03 | 6SS+7d | 120d |  |  |  |
| 8 | 1.1.3.3 | Balance Energético | 46d | 2016-01-18 | 2016-03-03 | 6SS+7d | 120d |  |  |  |
| 9 | 1.1.4 | **Estudios Topográficos y Geotécnicos de los Terrenos** | 20d | 2016-01-08 | 2016-01-27 |  | 156d |  |  |  |
| 10 | 1.1.4.1 | Estudios Topográficos | 12d | 2016-01-08 | 2016-01-19 |  | 164d |  | start no earlier than 2016-01-08 |  |
| 11 | 1.1.4.2 | Estudio de Geotécnicos | 20d | 2016-01-08 | 2016-01-27 |  | 156d |  | start no earlier than 2016-01-08 |  |
| 12 | 1.1.5 | **Emisión de Documento Soporte de Decisión 1 (DSD)** | 1d | 2016-03-03 | 2016-03-03 |  | 0d |  |  |  |
| 13 | 1.1.5.1 | Metodología | 1d | 2016-03-03 | 2016-03-03 |  | 0d |  | start no earlier than 2016-03-03 |  |
| 14 | 1.1.5.2 | Poblaciones Seleccionadas | 1d | 2016-03-03 | 2016-03-03 |  | 0d |  | start no earlier than 2016-03-03 |  |
| 15 | 1.1.5.3 | Proyección de la demanda de gas natural | 1d | 2016-03-03 | 2016-03-03 |  | 0d |  | start no earlier than 2016-03-03 |  |
| 16 | 1.1.5.4 | Balance energético | 1d | 2016-03-03 | 2016-03-03 |  | 0d |  | start no earlier than 2016-03-03 |  |
| 17 | 1.1.5.5 | Estudios topográficos | 1d | 2016-03-03 | 2016-03-03 |  | 0d |  | start no earlier than 2016-03-03 |  |
| 18 | 1.1.5.6 | Estudios de suelos | 1d | 2016-03-03 | 2016-03-03 |  | 0d |  | start no earlier than 2016-03-03 |  |
| 19 | 1.2 | **Documento Soporte de Decisión 2** | 40d | 2016-03-04 | 2016-04-12 |  | 0d |  |  |  |
| 20 | 1.2.1 | Evaluación Tecnica - Económica de Alternativas de Suministro de Gas Natural | 21d | 2016-03-04 | 2016-03-24 | 12 | 0d |  |  |  |
| 21 | 1.2.2 | Estrategia de implementación del proyecto | 14d | 2016-03-11 | 2016-03-24 | 20SS+7d | 14d |  |  |  |
| 22 | 1.2.3 | Sistema Logístico de Transporte | 21d | 2016-03-18 | 2016-04-07 | 20SS+14d | 0d |  |  |  |
| 23 | 1.2.4 | Emisión de Documento Soporte de Decisión 2 (DSD) | 5d | 2016-04-08 | 2016-04-12 | 20, 21, 22 | 0d |  |  |  |
| 24 | 1.3 | **Documento Soporte de Decisión 3** | 75d | 2016-04-08 | 2016-06-21 |  | 0d |  |  |  |
| 25 | 1.3.1 | **Desarrollo del diseño de las Estaciones de Gas Virtual** | 72d | 2016-04-08 | 2016-06-18 |  | 0d |  |  |  |
| 26 | 1.3.1.1 | Dimencionamiento de las ESR y ESD | 21d | 2016-04-13 | 2016-05-03 | 23 | 46d |  |  |  |
| 27 | 1.3.1.2 | Clasificación de Configuraciones de ESR y ESD | 21d | 2016-04-13 | 2016-05-03 | 23 | 0d |  |  |  |
| 28 | 1.3.1.3 | Elaboración y Descripción del Proceso de ESR y ESD | 21d | 2016-04-13 | 2016-05-03 | 23 | 46d |  |  |  |
| 29 | 1.3.1.4 | Diagramas de Proceso e Instrumentación (P&ID) de ESR y ESD | 21d | 2016-04-13 | 2016-05-03 | 23 | 46d |  |  |  |
| 30 | 1.3.1.5 | Desarrollo del HAZID y HAZOP | 30d | 2016-04-13 | 2016-05-12 | 23 | 37d |  |  |  |
| 31 | 1.3.1.6 | Listado de Equipos de ESR y ESD | 21d | 2016-04-13 | 2016-05-03 | 23 | 46d |  |  |  |
| 32 | 1.3.1.7 | Hojas de Especificaciones Técnicas de los equipos de las ESR y ESD | 30d | 2016-04-13 | 2016-05-12 | 23 | 37d |  |  |  |
| 33 | 1.3.1.8 | Listado del sistema de tuberias de ESR y ESD | 21d | 2016-04-13 | 2016-05-03 | 23 | 46d |  |  |  |
| 34 | 1.3.1.9 | Listado de Válvulas de ESR y ESD | 21d | 2016-04-13 | 2016-05-03 | 23 | 46d |  |  |  |
| 35 | 1.3.1.10 | Listado de Instrumentación de ESR y ESD | 21d | 2016-04-13 | 2016-05-03 | 23 | 46d |  |  |  |
| 36 | 1.3.1.11 | Especificaciones del sistema eléctrico de las ESR y ESD | 30d | 2016-04-13 | 2016-05-12 | 23 | 37d |  |  |  |
| 37 | 1.3.1.12 | Sistema de Transmisión de datos de Cisternas, ESR y ESD | 21d | 2016-04-13 | 2016-05-03 | 23 | 46d |  |  |  |
| 38 | 1.3.1.13 | Dimensiones Generales y Peso de equipos de ESR y ESD | 21d | 2016-04-13 | 2016-05-03 | 23 | 46d |  |  |  |
| 39 | 1.3.1.14 | Descripción de Cisternas para GNL y GNC | 21d | 2016-04-08 | 2016-04-28 | 22 | 51d |  |  |  |
| 40 | 1.3.1.15 | Descripción del Regasificadores Móviles | 21d | 2016-04-08 | 2016-04-28 | 22 | 51d |  |  |  |
| 41 | 1.3.1.16 | Diagramas de Proceso e Instrumentación (P&ID) para Regasificador Móvil | 21d | 2016-04-08 | 2016-04-28 | 22 | 51d |  |  |  |
| 42 | 1.3.1.17 | Especificaciones Técnicas del Cisterna para GNL y GNC | 30d | 2016-04-08 | 2016-05-07 | 22 | 42d |  |  |  |
| 43 | 1.3.1.18 | Especificaciones Técnicas del Regasificador Movil | 30d | 2016-04-08 | 2016-05-07 | 22 | 42d |  |  |  |
| 44 | 1.3.1.19 | Especificaciones Técnicas de Camiones y Tracto Camiones | 21d | 2016-04-08 | 2016-04-28 | 22 | 51d |  |  |  |

Notes:
- 1: DGV

| ID | WBS | Task | Duration | Start | Finish | Predecessors | Total slack | Free slack |
| --- | --- | --- | --- | --- | --- | --- | --- | --- |
| 45 | 1.3.1.20 | **Obras Civiles para ESR** | 34d | 2016-04-13 | 2016-05-16 |  | 17d |  |
| 46 | 1.3.1.20.1 | Diseño general y detalles constructivos de obras civiles para la construcción de 11 ESR | 25d | 2016-04-13 | 2016-05-07 | 23 | 17d | 0d |
| 47 | 1.3.1.20.2 | Computos Métricos de las obras civiles para la construcción de 11 ESR | 5d | 2016-05-08 | 2016-05-12 | 46 | 21d |  |
| 48 | 1.3.1.20.3 | Análisis de Precios Unitarios de las obras civiles para la construccion de 11 ESR | 5d | 2016-05-08 | 2016-05-12 | 46 | 17d | 0d |
| 49 | 1.3.1.20.4 | Presupuesto General de obras civiles para la construcción de 11 ESR | 2d | 2016-05-13 | 2016-05-14 | 48 | 17d | 0d |
| 50 | 1.3.1.20.5 | Cronograma de Actividades de las obras civiles para la cosntrucción de 11 ESR | 2d | 2016-05-15 | 2016-05-16 | 49 | 17d |  |
| 51 | 1.3.1.21 | **Diseño preliminar de Obras Civiles para Estaciones de Gas Virtual de la Fase de Ampliación** | 34d | 2016-04-13 | 2016-05-16 |  | 17d |  |
| 52 | 1.3.1.21.1 | Diseño general y detalles constructivos de obras civiles para la construcción de las ESR y ESD | 25d | 2016-04-13 | 2016-05-07 | 23 | 17d | 0d |
| 53 | 1.3.1.21.2 | Computos Métricos de las obras civiles para la construcción de las ESR y ESD | 5d | 2016-05-08 | 2016-05-12 | 52 | 21d |  |
| 54 | 1.3.1.21.3 | Análisis de Precios Unitarios de las obras civiles para la construccion de las ESR y ESD | 5d | 2016-05-08 | 2016-05-12 | 52 | 17d | 0d |
| 55 | 1.3.1.21.4 | Presupuesto General de obras civiles para la construcción de las ESR y ESD | 2d | 2016-05-13 | 2016-05-14 | 54 | 17d | 0d |
| 56 | 1.3.1.21.5 | Cronograma de Actividades de las obras civiles para la cosntrucción de las ESR y ESD | 2d | 2016-05-15 | 2016-05-16 | 55 | 17d |  |
| 57 | 1.3.1.22 | **Obras Mecánicas para ESR** | 30d | 2016-05-04 | 2016-06-02 |  | 0d |  |
| 58 | 1.3.1.22.1 | Computos Métricos de la instalación, obras mecánicas, pre-comisionado, comisionado y puesta en marcha de 10 ESR | 21d | 2016-05-04 | 2016-05-24 | 27 | 0d |  |
| 59 | 1.3.1.22.2 | Análisis de Precios Unitarios de la instalación, obras mecánicas, pre-comisionado, comisionado y puesta en marchan de 10 ESR | 4d | 2016-05-25 | 2016-05-28 | 58 | 0d |  |
| 60 | 1.3.1.22.3 | Presupuesto General de la instalación, obras mecánicas, pre-comisionado, comisionado y puesta en marcha de 10 ESR | 3d | 2016-05-29 | 2016-05-31 | 59 | 0d |  |
| 61 | 1.3.1.22.4 | Cronograma de Actividades de la instalación, obras mecánicas, pre-comisionado, comisionado y puesta en marcha de 10 ESR | 2d | 2016-06-01 | 2016-06-02 | 60 | 0d |  |
| 62 | 1.3.1.23 | **Obras Mecánicas para Estaciones de Gas Virtual de la Fase de Ampliación** | 30d | 2016-05-04 | 2016-06-02 |  | 0d |  |
| 63 | 1.3.1.23.1 | Computos Métricos de la instalación, obras mecánicas, pre-comisionado, comisionado y puesta en marcha de las ESR y ESD | 21d | 2016-05-04 | 2016-05-24 | 27 | 0d |  |
| 64 | 1.3.1.23.2 | Análisis de Precios Unitarios de la instalación, obras mecánicas, pre-comisionado, comisionado y puesta en marcha de las ESR y ESD | 5d | 2016-05-25 | 2016-05-29 | 63 | 0d |  |
| 65 | 1.3.1.23.3 | Presupuesto General de la instalación, obras mecánicas, pre-comisionado, comisionado y puesta en marcha de las ESR y ESD | 2d | 2016-05-30 | 2016-05-31 | 64 | 0d |  |
| 66 | 1.3.1.23.4 | Cronograma de Actividades de la instalación, obras mecánicas, pre-comisionado, comisionado y puesta en marcha de las ESR y ESD | 2d | 2016-06-01 | 2016-06-02 | 65 | 0d |  |
| 67 | 1.3.1.24 | Cronograma del desarrollo de la IPC | 16d | 2016-06-03 | 2016-06-18 | 45, 51, 57, 62 | 0d |  |
| 68 | 1.3.1.25 | Elaboración del Estudio Económico del Proyecto | 40d | 2016-04-23 | 2016-06-01 | 27SS+10d | 17d |  |

| ID | WBS | Task | Duration | Start | Finish | Predecessors | Total slack |
| --- | --- | --- | --- | --- | --- | --- | --- |
| 69 | 1.3.2 | **Emision de Documento Soporte de Decisión 3 (DSD)** | 3d | 2016-06-19 | 2016-06-21 |  | 0d |
| 70 | 1.3.2.1 | Especificaciones Técnicas para realizar la Ingeniería de Detalle | 3d | 2016-06-19 | 2016-06-21 | 25 | 0d |
| 71 | 1.3.2.2 | Montos de inversión para la IPC | 3d | 2016-06-19 | 2016-06-21 | 25 | 0d |
| 72 | 1.3.2.3 | Cronograma del desarrollo de la IPC | 3d | 2016-06-19 | 2016-06-21 | 25 | 0d |
| 73 | 1.3.2.4 | Modelo de Flujo de Caja para el Proyecto | 3d | 2016-06-19 | 2016-06-21 | 25 | 0d |
| 74 | 1.4 | Emision de Informe Final | 10d | 2016-06-22 | 2016-07-01 | 69 | 0d |
